# نیروگاه خورشیدی یزد- پترو کاویان صنعت پارس

Schedule from MS Project, 2026-01-11 to 2026-09-21.

## Calendars

- Standard: Mon-Sun 08:00-12:00, 13:00-17:00. Exceptions (off unless hours are given): 2026-03-20 to 2026-03-24 (عید نوروز).

## Schedule

| ID | WBS | Task | Type | Duration | Start | Finish | Predecessors | Total slack | Free slack | Constraint | start shamsi | finish shamsi |
| --- | --- | --- | --- | --- | --- | --- | --- | --- | --- | --- | --- | --- |
| 1 | 1 | شروع | milestone | 0d | 2026-01-11 | 2026-01-11 |  | 15d | 0d |  | 1404/10/21 | 1404/10/21 |
| 2 | 2 | **مایلستون های کلیدی** |  | 237d | 2026-01-11 | 2026-09-09 |  | 0d |  |  | 1404/10/21 | 1405/6/18 |
| 3 | 2.1 | دریافت سایر اطلاعات مقدماتی از کارفرما (آزمایش شیمیایی خاک، تست کشش پایه ها و…) | milestone | 0d | 2026-02-15 | 2026-02-15 | 1FS+13d, 4FS+13d | 5d | 0d |  | 1404/11/26 | 1404/11/26 |
| 4 | 2.2 | واریز اولین پیش پرداخت بخش مهندسی | milestone | 0d | 2026-02-03 | 2026-02-03 | 1 | 0d |  | must start on 2026-02-03 | 1404/11/14 | 1404/11/14 |
| 5 | 2.3 | دریافت مطالعات ژئوتکنیک | milestone, manual | 0d | 2026-01-11 | 2026-01-11 | 1, 4 |  |  |  | 1404/11/14 | 1404/11/14 |
| 6 | 2.4 | تحویل زمین | milestone | 0d | 2026-01-26 | 2026-01-26 | 1 | 0d |  | must start on 2026-01-26 | 1404/11/6 | 1404/11/6 |
| 7 | 2.5 | تاییدیه تجهیزات (پنل، اینورتر و MVStation( | milestone | 0d | 2026-02-03 | 2026-02-03 | 1, 4 | 8d | 0d |  | 1404/11/14 | 1404/11/14 |
| 8 | 2.6 | اتمام طراحی و اخذ تاییدیه | milestone | 0d | 2026-03-07 | 2026-03-07 | 21, 22, 23, 24, 25, 27, 28, 29, 30, 31, 32, 33, 34, 45, 36, 37, 38, 39, 40, 41, 42, 43, 44, 46, 47, 48, 49, 50, 51, 52, 54, 55, 56, 57, 58, 59, 60, 61, 62, 63, 64, 65, 66, 67, 68, 69, 70, 71, 72, 73, 74, 75, 76, 77, 78, 81, 82, 83, 84, 86, 87, 88, 89, 91, 92, 93, 94, 95, 96, 97 | 11d | 3d |  | 1404/12/16 | 1404/12/16 |
| 9 | 2.7 | اتمام استعلام قیمتی و سفارش گذاری خرید خارجی | milestone | 0d | 2026-02-28 | 2026-02-28 | 130, 136, 142, 148 | 18d | 0d |  | 1404/12/9 | 1404/12/9 |
| 10 | 2.8 | اتمام تامین و تحویل خرید خارجی در سایت پروژه | milestone | 0d | 2026-07-22 | 2026-07-22 | 134, 140, 146, 152 | 27d | 0d |  | 1405/4/31 | 1405/4/31 |
| 11 | 2.9 | اتمام تجهیز کارگاه | milestone | 0d | 2026-03-10 | 2026-03-10 | 155, 156, 157 | 8d | 0d |  | 1404/12/19 | 1404/12/19 |
| 12 | 2.10 | اتمام نصب سازه | milestone | 0d | 2026-07-20 | 2026-07-20 | 201 | 48d | 33d |  | 1405/4/29 | 1405/4/29 |
| 13 | 2.11 | اتمام نصب پنل | milestone | 0d | 2026-08-22 | 2026-08-22 | 202 | 15d | 10d |  | 1405/5/31 | 1405/5/31 |
| 14 | 2.12 | اتمام ساختمان مانیتورینگ | milestone | 0d | 2026-09-06 | 2026-09-06 | 186 | 9d | 0d |  | 1405/6/15 | 1405/6/15 |
| 15 | 2.13 | اتمام نصب MVStaion | milestone | 0d | 2026-07-24 | 2026-07-24 | 214 | 52d | 44d |  | 1405/5/2 | 1405/5/2 |
| 16 | 2.14 | اتمام نصب اینورتر | milestone | 0d | 2026-07-30 | 2026-07-30 | 205 | 27d |  |  | 1405/5/8 | 1405/5/8 |
| 17 | 2.15 | تست پست بالادست | milestone | 0d | 2026-09-09 | 2026-09-09 | 243 | 8d |  |  | 1405/6/18 | 1405/6/18 |
| 18 | 2.16 | تست های برق منطقه ای | milestone | 0d | 2026-01-11 | 2026-01-11 |  | 249d |  |  | 1404/10/21 | 1404/10/21 |
| 19 | 3 | **مهندسی** |  | 56d | 2026-01-11 | 2026-03-07 |  | 31d |  |  | 1404/10/21 | 1404/12/16 |
| 20 | 3.1 | **طراحی و اخذ تاییدیه طراحی پایه** |  | 12d | 2026-02-03 | 2026-02-14 |  | 8d |  |  | 1404/11/14 | 1404/11/25 |
| 21 | 3.1.1 | ارایه و اخذ تاییدیه دیتاشیت ها |  | 4d | 2026-02-03 | 2026-02-06 | 7 | 8d | 0d |  | 1404/11/14 | 1404/11/17 |
| 22 | 3.1.2 | ارایه و اخذ تاییدیه PVSYST Report |  | 4d | 2026-02-07 | 2026-02-10 | 21 | 8d | 0d |  | 1404/11/18 | 1404/11/21 |
| 23 | 3.1.3 | ارایه و اخذ تاییدیه General layout |  | 4d | 2026-02-07 | 2026-02-10 | 22SS | 8d | 0d |  | 1404/11/18 | 1404/11/21 |
| 24 | 3.1.4 | ارایه و اخذ تاییدیه General Single Line Diagram (GSLD) |  | 4d | 2026-02-11 | 2026-02-14 | 23 | 10d | 0d |  | 1404/11/22 | 1404/11/25 |
| 25 | 3.1.5 | ارایه و اخذ تاییدیه Plant Detailed Report |  | 4d | 2026-02-11 | 2026-02-14 | 22 | 10d | 0d |  | 1404/11/22 | 1404/11/25 |

| ID | WBS | Task | Duration | Start | Finish | Predecessors | Total slack | Free slack | start shamsi | finish shamsi |
| --- | --- | --- | --- | --- | --- | --- | --- | --- | --- | --- |
| 26 | 3.2 | **طراحی و اخذ تاییدیه عمرانی مطابق MDL ارایه شده** | 52d | 2026-01-11 | 2026-03-03 |  | 15d |  | 1404/10/21 | 1404/12/12 |
| 27 | 3.2.1 | Topography of Field | 4d | 2026-02-16 | 2026-02-19 | 3, 6 | 15d | 0d | 1404/11/27 | 1404/11/30 |
| 28 | 3.2.2 | Geotechnical Test Report | 4d | 2026-02-16 | 2026-02-19 | 3 | 19d | 0d | 1404/11/27 | 1404/11/30 |
| 29 | 3.2.3 | Ramming and Pull-Out Test Report | 4d | 2026-02-16 | 2026-02-19 | 3 | 5d | 0d | 1404/11/27 | 1404/11/30 |
| 30 | 3.2.4 | Hydrology Study Report | 4d | 2026-02-16 | 2026-02-19 | 3 | 19d | 0d | 1404/11/27 | 1404/11/30 |
| 31 | 3.2.5 | Site Fence Detail Drawing | 4d | 2026-02-20 | 2026-02-23 | 3, 27 | 15d | 0d | 1404/12/1 | 1404/12/4 |
| 32 | 3.2.6 | Logistic Area | 4d | 2026-02-11 | 2026-02-14 | 23 | 12d | 0d | 1404/11/22 | 1404/11/25 |
| 33 | 3.2.7 | Buildings Foundation & Structure Drawing | 4d | 2026-02-16 | 2026-02-19 | 5, 3 | 11d | 0d | 1404/11/27 | 1404/11/30 |
| 34 | 3.2.8 | Parking Foundation & Structure Detail Drawing | 4d | 2026-02-16 | 2026-02-19 | 5, 3 | 27d | 16d | 1404/11/27 | 1404/11/30 |
| 35 | 3.2.9 | Power Plant Entrance Gate Drawing | 4d | 2026-02-24 | 2026-02-27 | 3, 31 | 15d | 0d | 1404/12/5 | 1404/12/8 |
| 36 | 3.2.10 | Parking Architectural Drawing | 4d | 2026-02-15 | 2026-02-18 | 32, 23 | 28d | 17d | 1404/11/26 | 1404/11/29 |
| 37 | 3.2.11 | Landscaping Layout | 4d | 2026-02-11 | 2026-02-14 | 23 | 8d | 0d | 1404/11/22 | 1404/11/25 |
| 38 | 3.2.12 | Buildings Architectural Detail drawing | 4d | 2026-02-20 | 2026-02-23 | 33 | 11d | 0d | 1404/12/1 | 1404/12/4 |
| 39 | 3.2.13 | Fence MTO | 4d | 2026-02-24 | 2026-02-27 | 31 | 19d | 0d | 1404/12/5 | 1404/12/8 |
| 40 | 3.2.14 | Site Grading and Leveling | 4d | 2026-02-20 | 2026-02-23 | 27, 3, 28 | 23d | 12d | 1404/12/1 | 1404/12/4 |
| 41 | 3.2.15 | Drainage For Insite of Plant & Implementation Detail Drawing | 4d | 2026-02-20 | 2026-02-23 | 30, 23 | 19d | 0d | 1404/12/1 | 1404/12/4 |
| 42 | 3.2.16 | Flood Managmant For Outsite of Plant & Implementation Detail Drawing | 4d | 2026-02-24 | 2026-02-27 | 5, 30, 41 | 19d | 8d | 1404/12/5 | 1404/12/8 |
| 43 | 3.2.17 | Internal Road Layout & Implementation Detail Drawing | 4d | 2026-02-11 | 2026-02-14 | 23 | 24d | 0d | 1404/11/22 | 1404/11/25 |
| 44 | 3.2.18 | Access Road Layout & Implementation Detail Drawing | 4d | 2026-02-11 | 2026-02-14 | 23 | 24d | 0d | 1404/11/22 | 1404/11/25 |
| 45 | 3.2.19 | MV Station Foundation Drawings | 4d | 2026-02-07 | 2026-02-10 | 5, 7, 21 | 36d | 25d | 1404/11/18 | 1404/11/21 |
| 46 | 3.2.20 | Auxiliary Transformer Foundation Detail Drawings | 4d | 2026-01-11 | 2026-01-14 |  | 63d | 52d | 1404/10/21 | 1404/10/24 |
| 47 | 3.2.21 | Structure Detail Drawings | 4d | 2026-02-20 | 2026-02-23 | 3, 23, 29 | 5d | 0d | 1404/12/1 | 1404/12/4 |
| 48 | 3.2.22 | PV Structure Ramming Location Details Drawing (Stacking) | 4d | 2026-02-20 | 2026-02-23 | 23, 27, 28 | 19d | 0d | 1404/12/1 | 1404/12/4 |
| 49 | 3.2.23 | Solar Module Structure MTO | 4d | 2026-02-24 | 2026-02-27 | 47, 23 | 19d | 8d | 1404/12/5 | 1404/12/8 |
| 50 | 3.2.24 | Table UTM Point | 4d | 2026-02-24 | 2026-02-27 | 48 | 19d | 8d | 1404/12/5 | 1404/12/8 |
| 51 | 3.2.25 | Structure, Entrance Gate and Foundation of Building MTO | 4d | 2026-02-28 | 2026-03-03 | 35, 33, 38 | 15d | 0d | 1404/12/9 | 1404/12/12 |
| 52 | 3.2.26 | Site Mobilization Plan | 4d | 2026-02-15 | 2026-02-18 | 37, 43, 44, 32 | 28d | 17d | 1404/11/26 | 1404/11/29 |

| ID | WBS | Task | Duration | Start | Finish | Predecessors | Total slack | Free slack | start shamsi | finish shamsi |
| --- | --- | --- | --- | --- | --- | --- | --- | --- | --- | --- |
| 53 | 3.3 | **طراحی و اخذ تاییدیه الکتریکال مطابق MDL ارایه شده** | 29d | 2026-02-07 | 2026-03-07 |  | 18d |  | 1404/11/18 | 1404/12/16 |
| 54 | 3.3.1 | Solar Module, Connector, Inverter and MV station MTO | 4d | 2026-02-15 | 2026-02-18 | 22, 23, 25, 24 | 10d | 0d | 1404/11/26 | 1404/11/29 |
| 55 | 3.3.2 | Strings Connection Diagram & Inverter Arrangement (DC Side) | 4d | 2026-02-15 | 2026-02-18 | 23, 24 | 24d | 0d | 1404/11/26 | 1404/11/29 |
| 56 | 3.3.3 | Module & Table Arrangement (DC Side) | 4d | 2026-02-11 | 2026-02-14 | 23 | 28d | 4d | 1404/11/22 | 1404/11/25 |
| 57 | 3.3.4 | Electrical Cable Route and Section | 4d | 2026-02-11 | 2026-02-14 | 23 | 24d | 0d | 1404/11/22 | 1404/11/25 |
| 58 | 3.3.5 | Cable Trench Layout | 4d | 2026-02-11 | 2026-02-14 | 23 | 24d | 0d | 1404/11/22 | 1404/11/25 |
| 59 | 3.3.6 | DC Cable List, Labeling Code and MTO | 4d | 2026-02-19 | 2026-02-22 | 55, 56, 57, 58 | 24d | 0d | 1404/11/30 | 1404/12/3 |
| 60 | 3.3.7 | LV Cable Termination List and MTO | 4d | 2026-02-15 | 2026-02-18 | 57, 58 | 24d | 0d | 1404/11/26 | 1404/11/29 |
| 61 | 3.3.8 | LV Cable List, Labeling Code and MTO | 4d | 2026-02-19 | 2026-02-22 | 60 | 24d | 13d | 1404/11/30 | 1404/12/3 |
| 62 | 3.3.9 | MV Cable List, Labeling Code and MTO | 4d | 2026-02-15 | 2026-02-18 | 57, 58 | 24d | 0d | 1404/11/26 | 1404/11/29 |
| 63 | 3.3.10 | MV Cable Termination List and MTO | 4d | 2026-02-19 | 2026-02-22 | 62 | 24d | 0d | 1404/11/30 | 1404/12/3 |
| 64 | 3.3.11 | Earthing System Layout | 4d | 2026-02-15 | 2026-02-18 | 57, 58 | 28d | 17d | 1404/11/26 | 1404/11/29 |
| 65 | 3.3.12 | Lightning Protection Layout | 4d | 2026-02-11 | 2026-02-14 | 23 | 28d | 0d | 1404/11/22 | 1404/11/25 |
| 66 | 3.3.13 | Earthing and Lightning Protection MTO | 4d | 2026-02-15 | 2026-02-18 | 65 | 28d | 0d | 1404/11/26 | 1404/11/29 |
| 67 | 3.3.14 | Protection Single Line Diagram (PSLD) | 4d | 2026-02-15 | 2026-02-18 | 24 | 28d | 17d | 1404/11/26 | 1404/11/29 |
| 68 | 3.3.15 | MV Switchgear Logic Diagram | 4d | 2026-02-15 | 2026-02-18 | 21, 7, 24 | 20d | 0d | 1404/11/26 | 1404/11/29 |
| 69 | 3.3.16 | Trip Table | 4d | 2026-02-19 | 2026-02-22 | 68 | 24d | 13d | 1404/11/30 | 1404/12/3 |
| 70 | 3.3.17 | Alarm List | 4d | 2026-02-19 | 2026-02-22 | 68 | 24d | 13d | 1404/11/30 | 1404/12/3 |
| 71 | 3.3.18 | Indoor and Outdoor Electrical Plan & Details for Building | 4d | 2026-02-11 | 2026-02-14 | 23 | 32d | 21d | 1404/11/22 | 1404/11/25 |
| 72 | 3.3.19 | MV Switchgear MTO | 4d | 2026-02-15 | 2026-02-18 | 21, 7, 24 | 28d | 0d | 1404/11/26 | 1404/11/29 |
| 73 | 3.3.20 | Load List | 4d | 2026-03-04 | 2026-03-07 | 76, 77, 82, 83, 88, 92, 93, 95, 22, 25 | 11d | 0d | 1404/12/13 | 1404/12/16 |
| 74 | 3.3.21 | LVAC Auxiliary Panel Single Line Diagram | 4d | 2026-02-07 | 2026-02-10 | 21 | 32d | 4d | 1404/11/18 | 1404/11/21 |
| 75 | 3.3.22 | AUX Equipment MTO (AUX Transformer, Diesel, UPS, Battery, …) | 4d | 2026-02-15 | 2026-02-18 | 74, 22, 25 | 28d | 0d | 1404/11/26 | 1404/11/29 |
| 76 | 3.3.23 | Outdoor Lighting Pole Drawing | 4d | 2026-02-11 | 2026-02-14 | 23 | 24d | 0d | 1404/11/22 | 1404/11/25 |
| 77 | 3.3.24 | Outdoor Lighting Layout and Switchboard | 4d | 2026-02-15 | 2026-02-18 | 76 | 24d | 0d | 1404/11/26 | 1404/11/29 |
| 78 | 3.3.25 | Lighting System MTO | 4d | 2026-02-19 | 2026-02-22 | 76, 77 | 24d | 0d | 1404/11/30 | 1404/12/3 |
| 79 | 3.3.26 | Special Tools | 4d | 2026-02-07 | 2026-02-10 | 21 | 218d |  | 1404/11/18 | 1404/11/21 |

| ID | WBS | Task | Duration | Start | Finish | Predecessors | Total slack | Free slack | start shamsi | finish shamsi |
| --- | --- | --- | --- | --- | --- | --- | --- | --- | --- | --- |
| 80 | 3.4 | **طراحی و اخذ تاییدیه مکانیکال مطابق MDL ارایه شده** | 17d | 2026-02-15 | 2026-03-03 |  | 14d |  | 1404/11/26 | 1404/12/12 |
| 81 | 3.4.1 | Solar Panel Cleaning & Maintenance Procedures | 4d | 2026-02-20 | 2026-02-23 | 21, 3, 28 | 23d | 12d | 1404/12/1 | 1404/12/4 |
| 82 | 3.4.2 | HVAC Equipment Layout for Building | 4d | 2026-02-24 | 2026-02-27 | 38 | 11d | 0d | 1404/12/5 | 1404/12/8 |
| 83 | 3.4.3 | HVAC and Piping System MTO | 4d | 2026-02-28 | 2026-03-03 | 82 | 11d | 0d | 1404/12/9 | 1404/12/12 |
| 84 | 3.4.4 | Mechanical Drawing (Water Supply and Sewage Systems) | 4d | 2026-02-15 | 2026-02-18 | 32, 23 | 14d | 6d | 1404/11/26 | 1404/11/29 |
| 85 | 3.5 | **طراحی و اخذ تاییدیه ایمنی مطابق MDL ارایه شده** | 12d | 2026-02-24 | 2026-03-07 |  | 11d |  | 1404/12/5 | 1404/12/16 |
| 86 | 3.5.1 | Fire Fighting Equipment Arrangement of MV Switchgear Buildings | 4d | 2026-02-24 | 2026-02-27 | 38 | 11d | 0d | 1404/12/5 | 1404/12/8 |
| 87 | 3.5.2 | Outdoor Fire Fighting Equipment & Shelter Arrangement | 4d | 2026-02-28 | 2026-03-03 | 86 | 11d | 0d | 1404/12/9 | 1404/12/12 |
| 88 | 3.5.3 | Fire Alarm System Layout and Block Diagram | 4d | 2026-02-28 | 2026-03-03 | 86 | 11d | 0d | 1404/12/9 | 1404/12/12 |
| 89 | 3.5.4 | Fire and Safety and F & G System MTO | 4d | 2026-03-04 | 2026-03-07 | 87 | 11d | 0d | 1404/12/13 | 1404/12/16 |
| 90 | 3.6 | **طراحی و اخذ تاییدیه ارتباطی مطابق MDL ارایه شده** | 16d | 2026-02-11 | 2026-02-26 |  | 20d |  | 1404/11/22 | 1404/12/7 |
| 91 | 3.6.1 | CCTV System Block Diagram | 4d | 2026-02-11 | 2026-02-14 | 23 | 20d | 0d | 1404/11/22 | 1404/11/25 |
| 92 | 3.6.2 | CCTV System Arrangement & Layout | 4d | 2026-02-15 | 2026-02-18 | 91 | 20d | 0d | 1404/11/26 | 1404/11/29 |
| 93 | 3.6.3 | CCTV Pole Detail Drawing, Switchboard, CAFU Details | 4d | 2026-02-19 | 2026-02-22 | 92 | 20d | 0d | 1404/11/30 | 1404/12/3 |
| 94 | 3.6.4 | CCTV System MTO | 4d | 2026-02-23 | 2026-02-26 | 93 | 20d | 0d | 1404/12/4 | 1404/12/7 |
| 95 | 3.6.5 | Monitoring System Overall Diagram | 4d | 2026-02-19 | 2026-02-22 | 57, 68, 7, 21 | 20d | 0d | 1404/11/30 | 1404/12/3 |
| 96 | 3.6.6 | Telecommunication and Monitoring System MTO | 4d | 2026-02-23 | 2026-02-26 | 95 | 20d | 0d | 1404/12/4 | 1404/12/7 |
| 97 | 3.6.7 | SCADA System I/O | 4d | 2026-02-15 | 2026-02-18 | 7, 21, 24 | 28d | 0d | 1404/11/26 | 1404/11/29 |
| 98 | 4 | **تامین و حمل کالا تجهیزات** | 161d | 2026-02-07 | 2026-07-22 |  | 16d |  | 1404/11/18 | 1405/4/31 |
| 99 | 4.1 | **خرید و حمل داخلی** | 102d | 2026-02-15 | 2026-06-01 |  | 8d |  | 1404/11/26 | 1405/3/11 |
| 100 | 4.1.1 | کلیه کابل های فشار ضعیف نیروگاهac | 50d | 2026-02-19 | 2026-04-14 | 60 | 134d |  | 1404/11/30 | 1405/1/25 |
| 101 | 4.1.2 | کلیه کابل های فشار متوسط نیروگاهac | 50d | 2026-02-23 | 2026-04-18 | 63 | 141d | 135d | 1404/12/4 | 1405/1/29 |
| 102 | 4.1.3 | کابل dc | 20d | 2026-02-23 | 2026-03-14 | 59 | 161d | 156d | 1404/12/4 | 1404/12/23 |
| 103 | 4.1.4 | خرید تابلوهای فشار متوسط و کلیه متعلقات | 80d | 2026-02-19 | 2026-05-14 | 68 | 120d | 81d | 1404/11/30 | 1405/2/24 |
| 104 | 4.1.5 | کابل شبکه مورد نیازسیستم انتقال دیتا و اسکادا | 45d | 2026-02-23 | 2026-04-13 | 95, 97 | 145d | 135d | 1404/12/4 | 1405/1/24 |
| 105 | 4.1.6 | سیستم زمین نیروگاه | 43d | 2026-02-19 | 2026-04-07 | 66 | 143d | 141d | 1404/11/30 | 1405/1/18 |
| 106 | 4.1.7 | کلیه متعلقات مربوط به کابل کشی و سیم کشی | 32d | 2026-02-19 | 2026-03-27 | 72, 76 | 167d | 148d | 1404/11/30 | 1405/1/7 |
| 107 | 4.1.8 | تابلوهای فشار ضعیف و کلیه متعلقات | 30d | 2026-03-08 | 2026-04-11 | 24, 78, 73 | 155d | 114d | 1404/12/17 | 1405/1/22 |
| 108 | 4.1.9 | کلیه ملزومات و تجهیزات مربوط به ایجاد شبکه انتقال دیتا و بستر مخابراتی با پست بالادست | 50d | 2026-02-27 | 2026-04-22 | 97, 96 | 144d | 134d | 1404/12/8 | 1405/2/2 |
| 109 | 4.1.10 | کلیه ملزومات و تجهیزات مربوط به ایجاد شبکه انتقال دیتا و ارسال دیتا | 50d | 2026-02-19 | 2026-04-14 | 97 | 153d | 145d | 1404/11/30 | 1405/1/25 |
| 110 | 4.1.11 | یو پی اس | 38d | 2026-02-19 | 2026-04-02 | 75 | 166d | 142d | 1404/11/30 | 1405/1/13 |
| 111 | 4.1.12 | کلیه تجهیزات مربوط به دوربین(پایه و فونداسیون) | 50d | 2026-02-27 | 2026-04-22 | 94 | 134d | 126d | 1404/12/8 | 1405/2/2 |
| 112 | 4.1.13 | خرید سیستم روشنایی (پایه و فونداسیون) | 54d | 2026-02-23 | 2026-04-22 | 78 | 129d | 126d | 1404/12/4 | 1405/2/2 |
| 113 | 4.1.14 | سیستم اعلام حریق | 15d | 2026-03-08 | 2026-03-27 | 89 | 168d | 41d | 1404/12/17 | 1405/1/7 |
| 114 | 4.1.15 | سیستم اطفا حریق | 20d | 2026-03-04 | 2026-03-28 | 87 | 162d | 50d | 1404/12/13 | 1405/1/8 |
| 115 | 4.1.16 | سیستم حفاظت صاعقه | 43d | 2026-02-19 | 2026-04-07 | 66 | 160d | 158d | 1404/11/30 | 1405/1/18 |
| 116 | 4.1.17 | ترانسفورماتور کمکی و دیزل | 30d | 2026-02-19 | 2026-03-25 | 75 | 174d | 165d | 1404/11/30 | 1405/1/5 |
| 117 | 4.1.18 | لوازم یدکی Data logger | 73d | 2026-03-16 | 2026-06-01 | 118, 97 | 112d |  | 1404/12/25 | 1405/3/11 |
| 118 | 4.1.19 | ایستگاه هواشناسی و سنسورها | 25d | 2026-02-19 | 2026-03-15 | 97 | 112d | 0d | 1404/11/30 | 1404/12/24 |
| 119 | 4.1.20 | فنس پیرامونی | 20d | 2026-02-28 | 2026-03-19 | 39 | 19d | 11d | 1404/12/9 | 1404/12/28 |
| 120 | 4.1.21 | تانک سپتیک و دو مخزن 10 هزار لیتری سه لایه | 10d | 2026-02-15 | 2026-02-24 | 37 | 8d | 0d | 1404/11/26 | 1404/12/5 |
| 121 | 4.1.22 | کانکس نگهبانی | 10d | 2026-02-15 | 2026-02-24 | 32 | 14d | 6d | 1404/11/26 | 1404/12/5 |
| 122 | 4.1.23 | مواد و مصالح گیت ورودی | 20d | 2026-02-28 | 2026-03-19 | 35 | 58d | 50d | 1404/12/9 | 1404/12/28 |
| 123 | 4.1.24 | مصالح ساختمانی و ملزومات عمرانی (ساختمان های سوییچگیر و نگهبانی) | 30d | 2026-03-04 | 2026-04-07 | 51 | 39d | 0d | 1404/12/13 | 1405/1/18 |
| 124 | 4.1.25 | مصالح ،تجهیزات و ملزومات برقی (ساختمان های سوییچگیر و نگهبانی) | 30d | 2026-03-04 | 2026-04-07 | 51 | 127d | 30d | 1404/12/13 | 1405/1/18 |
| 125 | 4.1.26 | کلیه تجهیزات و ملزومات اداری | 15d | 2026-03-04 | 2026-03-18 | 51 | 160d | 0d | 1404/12/13 | 1404/12/27 |
| 126 | 4.1.27 | مصالح ،و تجهیزات ساختمان مانیتورینگ | 30d | 2026-03-04 | 2026-04-07 | 51 | 59d | 51d | 1404/12/13 | 1405/1/18 |
| 127 | 4.1.28 | خرید تجهیز کارگاه | 15d | 2026-02-15 | 2026-03-01 | 32 | 12d | 4d | 1404/11/26 | 1404/12/10 |

| ID | WBS | Task | Duration | Start | Finish | Predecessors | Total slack | Free slack | start shamsi | finish shamsi |
| --- | --- | --- | --- | --- | --- | --- | --- | --- | --- | --- |
| 128 | 4.2 | **خرید خارجی، حمل بین المللی و ترخیص** | 161d | 2026-02-07 | 2026-07-22 |  | 22d |  | 1404/11/18 | 1405/4/31 |
| 129 | 4.2.1 | **خرید سازه های نگهدارنده پنل ها و اینورترها** | 82d | 2026-02-24 | 2026-05-21 |  | 5d |  | 1404/12/5 | 1405/2/31 |
| 130 | 4.2.1.1 | استعلام قیمتی و سفارش گذاری سازه های نگهدارنده | 5d | 2026-02-24 | 2026-02-28 | 47, 54 | 5d | 0d | 1404/12/5 | 1404/12/9 |
| 131 | 4.2.1.2 | ساخت سازه های نگهدارنده و بازرسی قبل حمل | 20d | 2026-03-01 | 2026-03-25 | 130 | 5d | 0d | 1404/12/10 | 1405/1/5 |
| 132 | 4.2.1.3 | حمل خارجی سازه های نگهدارنده | 35d | 2026-03-26 | 2026-04-29 | 131 | 5d | 0d | 1405/1/6 | 1405/2/9 |
| 133 | 4.2.1.4 | ترخیص سازه های نگهدارنده | 15d | 2026-04-30 | 2026-05-14 | 132 | 5d | 0d | 1405/2/10 | 1405/2/24 |
| 134 | 4.2.1.5 | حمل داخلی سازه های نگهدارنده و تحویل در سایت | 7d | 2026-05-15 | 2026-05-21 | 133 | 5d | 0d | 1405/2/25 | 1405/2/31 |
| 135 | 4.2.2 | **خرید پنل های خورشیدی** | 118d | 2026-02-07 | 2026-06-09 |  | 18d |  | 1404/11/18 | 1405/3/19 |
| 136 | 4.2.2.1 | استعلام قیمتی و ثبت سفارش پنل های خورشیدی | 5d | 2026-02-07 | 2026-02-11 | 21 | 35d | 17d | 1404/11/18 | 1404/11/22 |
| 137 | 4.2.2.2 | ساخت پنل های خورشیدی و بازرسی قبل حمل | 30d | 2026-03-01 | 2026-04-04 | 136, 9 | 18d | 0d | 1404/12/10 | 1405/1/15 |
| 138 | 4.2.2.3 | حمل خارجی پنل های خورشیدی | 45d | 2026-04-05 | 2026-05-19 | 137 | 18d | 0d | 1405/1/16 | 1405/2/29 |
| 139 | 4.2.2.4 | ترخیص پنل های خورشیدی | 14d | 2026-05-20 | 2026-06-02 | 138 | 18d | 0d | 1405/2/30 | 1405/3/12 |
| 140 | 4.2.2.5 | حمل داخلی پنل های خورشیدی و تحویل در سایت | 7d | 2026-06-03 | 2026-06-09 | 139 | 18d | 13d | 1405/3/13 | 1405/3/19 |
| 141 | 4.2.3 | **خرید اینورترهای خورشیدی** | 149d | 2026-02-19 | 2026-07-22 |  | 21d |  | 1404/11/30 | 1405/4/31 |
| 142 | 4.2.3.1 | استعلام قیمتی ثبت سفارش اینورترهای خورشیدی | 7d | 2026-02-19 | 2026-02-25 | 21, 54 | 21d | 3d | 1404/11/30 | 1404/12/6 |
| 143 | 4.2.3.2 | ساخت اینورترهای خورشیدی و بازرسی قبل حمل | 73d | 2026-03-01 | 2026-05-17 | 142, 9 | 27d | 0d | 1404/12/10 | 1405/2/27 |
| 144 | 4.2.3.3 | حمل خارجی اینورترهای خورشیدی | 45d | 2026-05-18 | 2026-07-01 | 143 | 27d | 0d | 1405/2/28 | 1405/4/10 |
| 145 | 4.2.3.4 | ترخیص اینورترهای خورشیدی | 14d | 2026-07-02 | 2026-07-15 | 144 | 27d | 0d | 1405/4/11 | 1405/4/24 |
| 146 | 4.2.3.5 | حمل داخلی اینورترهای خورشیدی و تحویل در سایت | 7d | 2026-07-16 | 2026-07-22 | 145 | 27d | 0d | 1405/4/25 | 1405/4/31 |
| 147 | 4.2.4 | **خرید MV Station** | 149d | 2026-02-19 | 2026-07-22 |  | 21d |  | 1404/11/30 | 1405/4/31 |
| 148 | 4.2.4.1 | استعلام قیمتی ثبت سفارش MV Station | 7d | 2026-02-19 | 2026-02-25 | 21, 54 | 21d | 3d | 1404/11/30 | 1404/12/6 |
| 149 | 4.2.4.2 | ساخت MV Station و بازرسی قبل حمل | 73d | 2026-03-01 | 2026-05-17 | 148, 9 | 27d | 0d | 1404/12/10 | 1405/2/27 |
| 150 | 4.2.4.3 | حمل خارجی MV Station | 45d | 2026-05-18 | 2026-07-01 | 149 | 27d | 0d | 1405/2/28 | 1405/4/10 |
| 151 | 4.2.4.4 | ترخیص MV Station | 14d | 2026-07-02 | 2026-07-15 | 150 | 27d | 0d | 1405/4/11 | 1405/4/24 |
| 152 | 4.2.4.5 | حمل داخلی MV Station و تحویل در سایت | 7d | 2026-07-16 | 2026-07-22 | 151 | 27d | 0d | 1405/4/25 | 1405/4/31 |

Notes:
- 135: باراندازی کلی
- 137: 28 سنت یرو

| ID | WBS | Task | Duration | Start | Finish | Predecessors | Total slack | Free slack | Constraint | start shamsi | finish shamsi |
| --- | --- | --- | --- | --- | --- | --- | --- | --- | --- | --- | --- |
| 153 | 5 | **عملیات اجرایی** | 207d | 2026-02-15 | 2026-09-14 |  | 7d |  |  | 1404/11/26 | 1405/6/23 |
| 154 | 5.1 | **تجهیز کارگاه** | 14d | 2026-02-25 | 2026-03-10 |  | 8d |  |  | 1404/12/6 | 1404/12/19 |
| 155 | 5.1.1 | تانک سپتیک و دو مخزن 10 هزار لیتری سه لایه | 6d | 2026-02-25 | 2026-03-02 | 32, 84, 120 | 8d | 0d |  | 1404/12/6 | 1404/12/11 |
| 156 | 5.1.2 | کانکس نگهبانی | 3d | 2026-03-03 | 2026-03-05 | 32, 121, 155 | 8d | 0d |  | 1404/12/12 | 1404/12/14 |
| 157 | 5.1.3 | سایر تجهیز کارگاه | 5d | 2026-03-06 | 2026-03-10 | 32, 127, 156 | 8d | 0d |  | 1404/12/15 | 1404/12/19 |
| 158 | 5.2 | **اجرای جاده دسترسی تا جاده اصلی** | 8d | 2026-02-15 | 2026-02-22 |  | 24d |  |  | 1404/11/26 | 1404/12/3 |
| 159 | 5.2.1 | زیرسازی | 6d | 2026-02-15 | 2026-02-20 | 43, 44 | 24d | 0d |  | 1404/11/26 | 1404/12/1 |
| 160 | 5.2.2 | شن ریزی | 2d | 2026-02-21 | 2026-02-22 | 159 | 24d | 16d |  | 1404/12/2 | 1404/12/3 |
| 161 | 5.3 | **عملیات عمرانی** | 175d | 2026-03-11 | 2026-09-06 |  | 8d |  |  | 1404/12/20 | 1405/6/15 |
| 162 | 5.3.1 | **عملیات دسترسی و آماده سازی سایت** | 80d | 2026-03-11 | 2026-06-03 |  | 8d |  |  | 1404/12/20 | 1405/3/13 |
| 163 | 5.3.1.1 | تسطیح و تحکیم زمین | 20d | 2026-03-11 | 2026-04-04 | 40, 156, 8, 157, 11, 160 | 8d | 0d |  | 1404/12/20 | 1405/1/15 |
| 164 | 5.3.1.2 | اجرای گیت ورودی | 15d | 2026-05-14 | 2026-05-28 | 35, 122, 169 | 8d | 0d |  | 1405/2/24 | 1405/3/7 |
| 165 | 5.3.1.3 | احداث پارکینگ مسقف | 7d | 2026-05-28 | 2026-06-03 | 34, 36, 195 | 110d |  |  | 1405/3/7 | 1405/3/13 |
| 166 | 5.3.2 | اجرای سیستم زهکشی پیرامونی نیروگاه | 5d | 2026-08-12 | 2026-08-16 | 30, 41, 163, 27, 28, 42 | 0d |  | start no earlier than 2026-08-12 | 1405/5/21 | 1405/5/25 |
| 167 | 5.3.3 | **اجرای فنس پیرامونی** | 39d | 2026-04-05 | 2026-05-13 |  | 8d |  |  | 1405/1/16 | 1405/2/23 |
| 168 | 5.3.3.1 | اجرای فونداسیون و پایه فنس | 24d | 2026-04-05 | 2026-04-28 | 39, 119, 155, 163 | 8d | 0d |  | 1405/1/16 | 1405/2/8 |
| 169 | 5.3.3.2 | اجرای فنس | 35d | 2026-04-09 | 2026-05-13 | 168SS+4d | 8d | 0d |  | 1405/1/20 | 1405/2/23 |
| 170 | 5.3.4 | **اجرای فونداسیون MV Station** | 33d | 2026-06-19 | 2026-07-21 |  | 44d |  |  | 1405/3/29 | 1405/4/30 |
| 171 | 5.3.4.1 | گودبرداری فونداسیون | 3d | 2026-06-19 | 2026-06-21 | 45, 182 | 44d | 0d |  | 1405/3/29 | 1405/3/31 |
| 172 | 5.3.4.2 | بتن ریزی فونداسیون | 30d | 2026-06-22 | 2026-07-21 | 171 | 44d | 1d |  | 1405/4/1 | 1405/4/30 |
| 173 | 5.3.5 | **ساختمان پست سوییچگیر** | 118d | 2026-04-08 | 2026-08-03 |  | 39d |  |  | 1405/1/19 | 1405/5/12 |
| 174 | 5.3.5.1 | اجرای فونداسیون ساختمان پست سوییچگیر | 28d | 2026-04-08 | 2026-05-05 | 33, 30, 40, 42, 83, 123, 155 | 39d | 0d |  | 1405/1/19 | 1405/2/15 |
| 175 | 5.3.5.2 | سفت کاری ساختمان پست سوییچگیر | 60d | 2026-05-06 | 2026-07-04 | 174 | 39d | 0d |  | 1405/2/16 | 1405/4/13 |
| 176 | 5.3.5.3 | اجرای تاسیسات ساختمان پست سوییچگیر | 10d | 2026-07-05 | 2026-07-14 | 175, 124 | 39d | 0d |  | 1405/4/14 | 1405/4/23 |
| 177 | 5.3.5.4 | نازک کاری ساختمان پست سوییچگیر | 10d | 2026-07-15 | 2026-07-24 | 176 | 39d | 0d |  | 1405/4/24 | 1405/5/2 |
| 178 | 5.3.5.5 | اجرای نمای ساختمان پست سوییچگیر | 10d | 2026-07-25 | 2026-08-03 | 177 | 39d | 0d |  | 1405/5/3 | 1405/5/12 |
| 179 | 5.3.5.6 | اجرای سیستم اعلام حریق ساختمان پست سوییچگیر | 5d | 2026-07-05 | 2026-07-09 | 175, 113 | 69d | 34d |  | 1405/4/14 | 1405/4/18 |
| 180 | 5.3.5.7 | اجرای سیستم اطفا حریق ساختمان پست سوییچگیر | 5d | 2026-07-15 | 2026-07-19 | 176, 114 | 54d | 15d |  | 1405/4/24 | 1405/4/28 |

Notes:
- 166: پیانکار سفت کاری ساختمان در زمان دیار چیی استارت ای عملیت را نی می تواند بزند.بدلی عدم مناسب بودن اجرا در روزهای ابتدایی بدلی تردد ماشی آلات و موارد دیر که موجب بار آمدن خرابی کانال میود.

| ID | WBS | Task | Duration | Start | Finish | Predecessors | Total slack | Free slack | start shamsi | finish shamsi |
| --- | --- | --- | --- | --- | --- | --- | --- | --- | --- | --- |
| 181 | 5.3.6 | **ساختمان مانیتورینگ** | 167d | 2026-03-19 | 2026-09-06 |  | 10d |  | 1404/12/28 | 1405/6/15 |
| 182 | 5.3.6.1 | اجرای فونداسیون ساختمان مانیتورینگ | 21d | 2026-05-29 | 2026-06-18 | 33, 30, 40, 42, 83, 126, 155, 164 | 8d | 0d | 1405/3/8 | 1405/3/28 |
| 183 | 5.3.6.2 | سفت کاری ساختمان مانیتورینگ | 50d | 2026-06-19 | 2026-08-07 | 182 | 8d | 0d | 1405/3/29 | 1405/5/16 |
| 184 | 5.3.6.3 | اجرای تاسیسات ساختمان مانیتورینگ | 10d | 2026-08-08 | 2026-08-17 | 183 | 8d | 0d | 1405/5/17 | 1405/5/26 |
| 185 | 5.3.6.4 | نازک کاری ساختمان مانیتورینگ | 10d | 2026-08-18 | 2026-08-27 | 184 | 8d | 0d | 1405/5/27 | 1405/6/5 |
| 186 | 5.3.6.5 | اجرای نمای ساختمان مانیتورینگ | 10d | 2026-08-28 | 2026-09-06 | 185, 189 | 8d | 0d | 1405/6/6 | 1405/6/15 |
| 187 | 5.3.6.6 | اجرای سیستم اعلام حریق ساختمان مانیتورینگ | 5d | 2026-08-08 | 2026-08-12 | 183, 113 | 35d | 0d | 1405/5/17 | 1405/5/21 |
| 188 | 5.3.6.7 | اجرای سیستم اطفا حریق ساختمان مانیتورینگ | 5d | 2026-08-18 | 2026-08-22 | 184, 114 | 24d | 0d | 1405/5/27 | 1405/5/31 |
| 189 | 5.3.6.8 | کلیه تجهیزات و ملزومات | 5d | 2026-03-19 | 2026-03-28 | 32, 125 | 160d | 152d | 1404/12/28 | 1405/1/8 |
| 190 | 5.3.7 | **ساختمان نگهبانی** | 50d | 2026-04-08 | 2026-05-27 |  | 110d |  | 1405/1/19 | 1405/3/6 |
| 191 | 5.3.7.1 | اجرای فونداسیون ساختمان نگهبانی | 10d | 2026-04-08 | 2026-04-17 | 33, 30, 40, 42, 83, 123, 155 | 110d | 0d | 1405/1/19 | 1405/1/28 |
| 192 | 5.3.7.2 | سفت کاری ساختمان نگهبانی | 20d | 2026-04-18 | 2026-05-07 | 191 | 110d | 0d | 1405/1/29 | 1405/2/17 |
| 193 | 5.3.7.3 | اجرای تاسیسات ساختمان نگهبانی | 10d | 2026-05-08 | 2026-05-17 | 192, 124 | 110d | 0d | 1405/2/18 | 1405/2/27 |
| 194 | 5.3.7.4 | نازک کاری ساختمان نگهبانی | 5d | 2026-05-18 | 2026-05-22 | 193 | 110d | 0d | 1405/2/28 | 1405/3/1 |
| 195 | 5.3.7.5 | اجرای نمای ساختمان نگهبانی | 5d | 2026-05-23 | 2026-05-27 | 194 | 110d | 0d | 1405/3/2 | 1405/3/6 |
| 196 | 5.3.7.6 | اجرای سیستم اعلام حریق ساختمان نگهبانی | 2d | 2026-05-08 | 2026-05-09 | 192, 113 | 130d | 95d | 1405/2/18 | 1405/2/19 |
| 197 | 5.3.7.7 | اجرای سیستم اطفا حریق ساختمان نگهبانی | 2d | 2026-05-18 | 2026-05-19 | 193, 114 | 120d | 95d | 1405/2/28 | 1405/2/29 |
| 198 | 5.4 | **عملیات مکانیکال** | 140d | 2026-04-05 | 2026-08-22 |  | 5d |  | 1405/1/16 | 1405/5/31 |
| 199 | 5.4.1 | نقشه برداری پایه ها و میخ کوبی | 6d | 2026-04-05 | 2026-04-10 | 23, 40, 50, 163 | 46d | 41d | 1405/1/16 | 1405/1/21 |
| 200 | 5.4.2 | پایه کوبی | 46d | 2026-05-22 | 2026-07-06 | 199, 134 | 5d | 0d | 1405/3/1 | 1405/4/15 |
| 201 | 5.4.3 | نصب متعلقات استراکچرها | 56d | 2026-05-26 | 2026-07-20 | 200SS+4d, 49 | 5d | 0d | 1405/3/5 | 1405/4/29 |
| 202 | 5.4.4 | نصب پنل ها | 61d | 2026-06-23 | 2026-08-22 | 201FS-5%, 140 | 5d | 0d | 1405/4/2 | 1405/5/31 |
| 203 | 5.5 | **عملیات الکتریکال** | 54d | 2026-07-23 | 2026-09-14 |  | 2d |  | 1405/5/1 | 1405/6/23 |
| 204 | 5.5.1 | اجرای ترانشه و کانال عبور فیبر نوری | 10d | 2026-08-17 | 2026-08-26 | 200FS-15d, 58, 57, 166 | 0d |  | 1405/5/26 | 1405/6/4 |
| 205 | 5.5.2 | نصب سازه اینورتر و وایرینگ اینورترهای سایت | 8d | 2026-07-23 | 2026-07-30 | 146, 134, 10 | 27d | 0d | 1405/5/1 | 1405/5/8 |
| 206 | 5.5.3 | اجرای سیستم زمین نیروگاه | 15d | 2026-08-27 | 2026-09-10 | 204, 64, 105 | 2d | 0d | 1405/6/5 | 1405/6/19 |
| 207 | 5.5.4 | تابلوهای فشار متوسط و کلیه متعلقات | 5d | 2026-08-04 | 2026-08-08 | 178, 180, 103 | 39d | 29d | 1405/5/13 | 1405/5/17 |
| 208 | 5.5.5 | تابلوهای فشار ضعیف و کلیه متعلقات | 2d | 2026-08-04 | 2026-08-05 | 71, 107, 178 | 41d | 35d | 1405/5/13 | 1405/5/14 |
| 209 | 5.5.6 | کلیه کابل های فشار ضعیف نیروگاهac | 15d | 2026-08-27 | 2026-09-10 | 204, 61, 57, 100, 205, 16 | 0d |  | 1405/6/5 | 1405/6/19 |
| 210 | 5.5.7 | کلیه کابل های فشار متوسط نیروگاهac | 6d | 2026-09-01 | 2026-09-06 | 204FS+5d, 57, 101 | 6d | 0d | 1405/6/10 | 1405/6/15 |
| 211 | 5.5.8 | کابل dc | 14d | 2026-08-23 | 2026-09-05 | 202, 201FS-10d, 102, 12FS-10d, 13FS-10d, 32 | 5d | 0d | 1405/6/1 | 1405/6/14 |
| 212 | 5.5.9 | اجرای کابل های فیبر نوری | 3d | 2026-08-27 | 2026-08-29 | 204, 104, 214 | 10d | 0d | 1405/6/5 | 1405/6/7 |
| 213 | 5.5.10 | نصب ایستگاه هواشناسی و سنسورها | 3d | 2026-07-25 | 2026-07-27 | 214, 118 | 49d | 41d | 1405/5/3 | 1405/5/5 |
| 214 | 5.5.11 | MV Station نصب | 2d | 2026-07-23 | 2026-07-24 | 172, 152, 10 | 43d | 0d | 1405/5/1 | 1405/5/2 |
| 215 | 5.5.12 | اجرای کلیه ملزومات و تجهیزات مربوط به ایجاد شبکه انتقال دیتا و بستر مخابراتی با پست بالادست به جز فیبر نوری | 3d | 2026-09-04 | 2026-09-06 | 212FS+5d, 108 | 10d | 0d | 1405/6/13 | 1405/6/15 |
| 216 | 5.5.13 | نصب ترانسفورماتور کمکی و دیزل | 1d | 2026-09-07 | 2026-09-07 | 188, 186, 116, 46, 14 | 9d | 2d | 1405/6/16 | 1405/6/16 |
| 217 | 5.5.14 | نصب یو پی اس | 1d | 2026-08-23 | 2026-08-23 | 188, 178, 110 | 24d | 17d | 1405/6/1 | 1405/6/1 |
| 218 | 5.5.15 | سیستم حفاظت صاعقه | 2d | 2026-09-13 | 2026-09-14 | 115, 67, 240 | 2d | 0d | 1405/6/22 | 1405/6/23 |
| 219 | 5.5.16 | اجرای کلیه ملزومات و تجهیزات مربوط به ایجاد شبکه انتقال دیتا و ارسال دیتا | 2d | 2026-09-07 | 2026-09-08 | 212, 178, 186, 104, 109, 213, 15 | 8d | 0d | 1405/6/16 | 1405/6/17 |

Notes:
- 204: پیانکار جدا دارد
- 205: هزیه ارتیگش هم ایجا دیه شده
- 206: اجرای برق گی و صاعقه گی رو هم با سیتم ارت دیم
- 211: به همراه سوکت زنی mc4
- 213: قبل مانیوریگ بای نصب و راه اندازی بشه
- 215: ای همون اسکادا هست که کار جمع آوری دیا رو انجام میه / کابل های دیا که تموم شد میه کارای راه اندازیم انجام دد و تستش کرد
- 219: اسکادا رو همپوشانی با خط انتقال انجام بده اما آر تی ی بای بعد اجرای بستر ارتباطی اجرا و نهایی بشه / هماهنگی های زیدی داره / اسکادا جمع آوری اطلاعات داخل سایه،آر تی ی برای انتقال دیای جمع آوری شده تویط اسکادا به سایه

| ID | WBS | Task | Duration | Start | Finish | Predecessors | Total slack | Free slack | start shamsi | finish shamsi |
| --- | --- | --- | --- | --- | --- | --- | --- | --- | --- | --- |
| 220 | 5.5.17 | **کلیه متعلقات مربوط به کابل کشی و سیم کشی** | 22d | 2026-08-23 | 2026-09-13 |  | 2d |  | 1405/6/1 | 1405/6/22 |
| 221 | 5.5.17.1 | نصب لدر | 3d | 2026-09-07 | 2026-09-09 | 178, 210 | 6d | 4d | 1405/6/16 | 1405/6/18 |
| 222 | 5.5.17.2 | اجرای لوله پلی اتیلن و فلکسی | 5d | 2026-08-23 | 2026-08-27 | 106, 211SS, 201 | 19d | 17d | 1405/6/1 | 1405/6/5 |
| 223 | 5.5.17.3 | اجرای سرسیم و کابل شو | 3d | 2026-09-11 | 2026-09-13 | 209, 211 | 0d |  | 1405/6/20 | 1405/6/22 |
| 224 | 5.5.17.4 | اجرای سر کابل | 2d | 2026-09-07 | 2026-09-08 | 210 | 7d | 0d | 1405/6/16 | 1405/6/17 |
| 225 | 5.5.18 | **نصب سیستم روشنایی** | 14d | 2026-08-27 | 2026-09-09 |  | 3d |  | 1405/6/5 | 1405/6/18 |
| 226 | 5.5.18.1 | اجرای فونداسیون سیستم روشنایی | 8d | 2026-08-27 | 2026-09-03 | 112, 76, 78, 169, 204 | 3d | 0d | 1405/6/5 | 1405/6/12 |
| 227 | 5.5.18.2 | کابل کشی سیستم روشنایی | 5d | 2026-08-27 | 2026-08-31 | 57, 204 | 16d | 9d | 1405/6/5 | 1405/6/9 |
| 228 | 5.5.18.3 | نصب پایه ها و چراغ ها | 6d | 2026-09-04 | 2026-09-09 | 226 | 3d | 0d | 1405/6/13 | 1405/6/18 |
| 229 | 5.5.19 | **CCTV نصب سیستم** | 9d | 2026-08-27 | 2026-09-04 |  | 8d |  | 1405/6/5 | 1405/6/13 |
| 230 | 5.5.19.1 | اجرای فونداسیون دوربین | 5d | 2026-08-27 | 2026-08-31 | 111, 93, 94, 155, 204 | 8d | 0d | 1405/6/5 | 1405/6/9 |
| 231 | 5.5.19.2 | کابل کشی دوربین ها | 5d | 2026-08-27 | 2026-08-31 | 57, 204, 104, 111 | 15d | 4d | 1405/6/5 | 1405/6/9 |
| 232 | 5.5.19.3 | نصب پایه ها و چراغ ها | 4d | 2026-09-01 | 2026-09-04 | 230 | 8d | 0d | 1405/6/10 | 1405/6/13 |
| 233 | 6 | **تست و تحویل** | 40d | 2026-08-13 | 2026-09-21 |  | 0d |  | 1405/5/22 | 1405/6/30 |
| 234 | 6.1 | **تست و راه اندازی نیروگاه** | 40d | 2026-08-13 | 2026-09-21 |  | 0d |  | 1405/5/22 | 1405/6/30 |
| 235 | 6.1.1 | تست کلیه کابل های فشار ضعیف نیروگاهac | 2d | 2026-09-14 | 2026-09-15 | 209, 223 | 2d |  | 1405/6/23 | 1405/6/24 |
| 236 | 6.1.2 | تست کلیه کابل های فشار متوسط نیروگاهac | 2d | 2026-09-09 | 2026-09-10 | 210, 224 | 7d |  | 1405/6/18 | 1405/6/19 |
| 237 | 6.1.3 | تست کابل dc | 4d | 2026-09-14 | 2026-09-17 | 211, 223 | 0d |  | 1405/6/23 | 1405/6/26 |
| 238 | 6.1.4 | تست تابلوهای فشار متوسط و کلیه متعلقات | 1d | 2026-09-07 | 2026-09-07 | 207, 186, 214 | 10d |  | 1405/6/16 | 1405/6/16 |
| 239 | 6.1.5 | تست کابل شبکه مورد نیازسیستم انتقال دیتا و اسکادا | 1d | 2026-09-07 | 2026-09-07 | 212, 213, 215, 231 | 10d |  | 1405/6/16 | 1405/6/16 |
| 240 | 6.1.6 | تست سیستم زمین نیروگاه | 2d | 2026-09-11 | 2026-09-12 | 206, 228, 232 | 2d | 0d | 1405/6/20 | 1405/6/21 |
| 241 | 6.1.7 | تست کلیه متعلقات مربوط به کابل کشی و سیم کشی | 2d | 2026-09-14 | 2026-09-15 | 221, 222, 223, 224 | 2d |  | 1405/6/23 | 1405/6/24 |
| 242 | 6.1.8 | تست تابلوهای فشار ضعیف و کلیه متعلقات | 2d | 2026-09-14 | 2026-09-15 | 208, 223, 228, 232 | 2d |  | 1405/6/23 | 1405/6/24 |
| 243 | 6.1.9 | تست کلیه ملزومات و تجهیزات مربوط به ایجاد شبکه انتقال دیتا و بستر مخابراتی با پست بالادست | 1d | 2026-09-09 | 2026-09-09 | 215, 207, 213, 214, 219 | 8d | 0d | 1405/6/18 | 1405/6/18 |
| 244 | 6.1.10 | تست کلیه ملزومات و تجهیزات مربوط به ایجاد شبکه انتقال دیتا و ارسال دیتا | 1d | 2026-09-09 | 2026-09-09 | 219, 207, 213, 214, 215 | 8d |  | 1405/6/18 | 1405/6/18 |
| 245 | 6.1.11 | تست یو پی اس | 1d | 2026-09-10 | 2026-09-10 | 217, 208, 228 | 7d |  | 1405/6/19 | 1405/6/19 |
| 246 | 6.1.12 | تست کلیه تجهیزات مربوط به دوربین | 2d | 2026-09-05 | 2026-09-06 | 231, 232 | 11d |  | 1405/6/14 | 1405/6/15 |
| 247 | 6.1.13 | تست سیستم روشنایی | 1d | 2026-09-10 | 2026-09-10 | 227, 228 | 7d |  | 1405/6/19 | 1405/6/19 |
| 248 | 6.1.14 | تست سیستم اعلام حریق | 1d | 2026-08-13 | 2026-08-13 | 179, 187, 196 | 35d |  | 1405/5/22 | 1405/5/22 |
| 249 | 6.1.15 | تست سیستم اطفا حریق | 1d | 2026-08-23 | 2026-08-23 | 180, 188, 197 | 25d |  | 1405/6/1 | 1405/6/1 |
| 250 | 6.1.16 | تست سیستم حفاظت صاعقه | 1d | 2026-09-15 | 2026-09-15 | 218, 240 | 2d |  | 1405/6/24 | 1405/6/24 |
| 251 | 6.1.17 | تست ترانسفورماتور کمکی و دیزل | 1d | 2026-09-10 | 2026-09-10 | 216, 224, 228, 232 | 7d |  | 1405/6/19 | 1405/6/19 |

| ID | WBS | Task | Type | Duration | Start | Finish | Predecessors | Total slack | start shamsi | finish shamsi |
| --- | --- | --- | --- | --- | --- | --- | --- | --- | --- | --- |
| 252 | 6.1.18 | **ارایه نقشه های ازبیلت** |  | 30d | 2026-08-23 | 2026-09-21 |  | 0d | 1405/6/1 | 1405/6/30 |
| 253 | 6.1.18.1 | ارایه نقشه های ازبیلت الکتریکال |  | 4d | 2026-09-18 | 2026-09-21 | 235, 236, 237, 238, 239, 240, 241, 242, 243, 244, 245, 246, 247, 248, 249, 250, 251, 17 | 0d | 1405/6/27 | 1405/6/30 |
| 254 | 6.1.18.2 | ارایه نقشه های ازبیلت مکانیکال |  | 7d | 2026-08-23 | 2026-08-29 | 202, 12 | 23d | 1405/6/1 | 1405/6/7 |
| 255 | 6.1.18.3 | ارایه نقشه های ازبیلت civil |  | 7d | 2026-09-07 | 2026-09-13 | 178, 186, 195, 172 | 8d | 1405/6/16 | 1405/6/22 |
| 256 | 6.2 | اتصال به شبکه و پلمپ کنتور |  | 1d | 2026-09-18 | 2026-09-18 | 235, 236, 237, 238, 239, 240, 241, 242, 243, 244, 245, 246, 247, 248, 249, 250, 251, 155 | 0d | 1405/6/27 | 1405/6/27 |
| 257 | 6.3 | آموزش |  | 6d | 2026-09-16 | 2026-09-21 | 256FS-3d, 81 | 0d | 1405/6/25 | 1405/6/30 |
| 258 | 6.4 | برچیدن کارگاه |  | 4d | 2026-09-16 | 2026-09-19 | 256FS-3d | 2d | 1405/6/25 | 1405/6/28 |
| 259 | 7 | پایان | milestone | 0d | 2026-09-21 | 2026-09-21 | 256, 257, 258, 253, 254, 255, 165, 117, 79 | 0d | 1405/6/30 | 1405/6/30 |
